# LCGT Plan Silica RSE Change Suspensions

Schedule from MS Project, 2012-04-01 to 2019-08-26.

## Calendars

- 働き詰め: Mon-Fri 08:00-12:00, 13:00-17:00; Sat-Sun 09:00-17:00.

## Resources

| Resource |
| --- |
| 8 |

## Schedule

| ID | WBS | Task | Type | Duration | Start | Finish | Predecessors | Total slack | Free slack | Constraint |
| --- | --- | --- | --- | --- | --- | --- | --- | --- | --- | --- |
| 1 | 1 | **Common Tasks** |  | 1461d | 2012-04-01 | 2016-03-31 |  | 0d |  |  |
| 2 | 1.1 | Excavation | manual | 730.12d | 2012-04-01 | 2014-03-31 |  |  |  |  |
| 3 | 1.2 | **Sapphire Mirror** |  | 1086d | 2013-04-11 | 2016-03-31 |  | 0d |  |  |
| 4 | 1.2.1 | ETM | manual | 24mo | 2013-04-11 | 2015-03-31 |  |  |  |  |
| 5 | 1.2.2 | ITM | manual | 24mo | 2014-04-12 | 2016-03-31 |  |  |  |  |
| 6 | 1.3 | **Vacuum Installation** |  | 365d | 2014-04-01 | 2015-03-31 |  |  |  |  |
| 7 | 1.3.1 | MC | manual | 1mo | 2014-04-01 | 2014-04-30 |  |  |  |  |
| 8 | 1.3.2 | ETMXA | manual | 1mo | 2014-04-01 | 2014-04-30 |  |  |  |  |
| 9 | 1.3.3 | ETMXB | manual | 1mo | 2014-04-01 | 2014-04-30 |  |  |  |  |
| 10 | 1.3.4 | ITMXA | manual | 1mo | 2014-09-01 | 2014-09-30 |  |  |  |  |
| 11 | 1.3.5 | ITMXB | manual | 1mo | 2014-09-01 | 2014-09-30 |  |  |  | start no earlier than 2014-09-01 |
| 12 | 1.3.6 | Central Part | manual | 1mo | 2014-09-01 | 2014-09-30 |  |  |  |  |
| 13 | 1.3.7 | ITMYA | manual | 1mo | 2014-09-01 | 2014-09-30 |  |  |  |  |
| 14 | 1.3.8 | ITMYB | manual | 1mo | 2014-09-01 | 2014-09-30 |  |  |  | start no earlier than 2014-09-01 |
| 15 | 1.3.9 | ETMYA | manual | 1mo | 2015-03-01 | 2015-03-30 |  |  |  |  |
| 16 | 1.3.10 | ETMYB | manual | 1mo | 2015-03-01 | 2015-03-30 |  |  |  | start no earlier than 2015-03-01 |
| 17 | 1.4 | **Cryostat** |  | 454d | 2014-04-01 | 2015-06-28 |  | 15d |  |  |
| 18 | 1.4.1 | Cryostat Install ETMX |  | 1mo | 2014-04-01 | 2014-04-30 | 8SS | 304d | 0d |  |
| 19 | 1.4.2 | Cryostat Test ETMX |  | 2mo | 2014-05-31 | 2014-07-29 | 18, 27 | 304d |  |  |
| 20 | 1.4.3 | Cryostat Install ITMX |  | 1mo | 2014-09-01 | 2014-09-30 | 10SS | 91d | 0d |  |
| 21 | 1.4.4 | Cryostat Test ITMX |  | 2mo | 2014-10-31 | 2014-12-29 | 20, 29 | 91d | 60d |  |
| 22 | 1.4.5 | Cryostat Install ITMY |  | 1mo | 2014-10-01 | 2014-10-30 | 13SS, 20 | 151d | 0d |  |
| 23 | 1.4.6 | Cryostat Test ITMY |  | 2mo | 2014-11-30 | 2015-01-28 | 22, 32 | 151d | 120d |  |
| 24 | 1.4.7 | Cryostat Install ETMY |  | 1mo | 2015-03-01 | 2015-03-30 | 15SS | 15d | 0d |  |
| 25 | 1.4.8 | Cryostat Test ETMY |  | 2mo | 2015-04-30 | 2015-06-28 | 24, 34 | 15d | 0d |  |

| ID | WBS | Task | Duration | Start | Finish | Predecessors | Total slack | Free slack |
| --- | --- | --- | --- | --- | --- | --- | --- | --- |
| 26 | 1.5 | **Clean Rooms** | 364d | 2014-05-01 | 2015-04-29 |  | 15d |  |
| 27 | 1.5.1 | ETMXA | 1mo | 2014-05-01 | 2014-05-30 | 8, 18 | 304d | 0d |
| 28 | 1.5.2 | ETMXB | 1mo | 2014-05-01 | 2014-05-30 | 9 | 334d | 0d |
| 29 | 1.5.3 | ITMXA | 1mo | 2014-10-01 | 2014-10-30 | 10, 20 | 91d | 0d |
| 30 | 1.5.4 | ITMXB | 1mo | 2014-10-01 | 2014-10-30 | 11 | 121d | 0d |
| 31 | 1.5.5 | Central Part | 1mo | 2014-10-01 | 2014-10-30 | 12 | 31d | 0d |
| 32 | 1.5.6 | ITMYA | 1mo | 2014-10-31 | 2014-11-29 | 13, 22 | 151d | 0d |
| 33 | 1.5.7 | ITMYB | 1mo | 2014-10-01 | 2014-10-30 | 14 | 181d | 0d |
| 34 | 1.5.8 | ETMYA | 1mo | 2015-03-31 | 2015-04-29 | 15, 24 | 15d | 0d |
| 35 | 1.5.9 | ETMYB | 1mo | 2015-03-31 | 2015-04-29 | 16 | 0d |  |
| 36 | 2 | **New Plan, Aux: StackB->TypeB, TM: StackB->TypeA** | 1944d | 2014-05-01 | 2019-08-26 |  | 0d |  |
| 37 | 2.1 | **iLCGT** | 829d | 2014-05-01 | 2016-08-06 |  | 60d |  |
| 38 | 2.1.1 | MC Suspension | 1mo | 2014-05-01 | 2014-05-30 | 7 | 244d | 0d |
| 39 | 2.1.2 | **Suspension Installation for iLCGT** | 364d | 2014-05-31 | 2015-05-29 |  | 0d |  |
| 40 | 2.1.2.1 | ETMX (StackB) | 1mo | 2014-05-31 | 2014-06-29 | 28 | 334d |  |
| 41 | 2.1.2.2 | ITMX (StackB) | 1mo | 2014-10-31 | 2014-11-29 | 30 | 121d | 90d |
| 42 | 2.1.2.3 | PRC, BS (StackB) | 4mo | 2014-10-31 | 2015-02-27 | 31 | 31d | 0d |
| 43 | 2.1.2.4 | ITMY (StackB) | 1mo | 2014-10-31 | 2014-11-29 | 33 | 181d | 180d |
| 44 | 2.1.2.5 | ETMY (StackB) | 1mo | 2015-04-30 | 2015-05-29 | 35 | 0d |  |
| 45 | 2.1.3 | **Type A Commissioning** | 435d | 2015-05-30 | 2016-08-06 | 39 | 0d |  |
| 46 | 2.1.3.1 | Type A Installation ETMX | 1.5mo | 2015-05-30 | 2015-07-13 | 19 | 0d |  |
| 47 | 2.1.3.2 | Cryogenic Payload Test ETMX | 6mo | 2015-07-14 | 2016-01-09 | 46 | 0d |  |
| 48 | 2.1.3.3 | TypeA+CryoPayload Test ETMX | 6mo | 2016-01-10 | 2016-07-07 | 47 | 0d |  |
| 49 | 2.1.3.4 | Type A Installation ETMY | 1.5mo | 2015-06-29 | 2015-08-12 | 25 | 15d | 0d |
| 50 | 2.1.3.5 | Type A Test ETMY | 6mo | 2015-08-13 | 2016-02-08 | 49 | 15d | 0d |
| 51 | 2.1.3.6 | CryoPayload Install and Test ETMY | 6mo | 2016-02-09 | 2016-08-06 | 50 | 15d |  |
| 52 | 2.1.3.7 | ITM SAS Install and Adjust | 6mo | 2015-11-26 | 2016-05-23 | 53 | 135d |  |
| 53 | 2.1.4 | SRC SAS Installation | 4.5mo | 2015-07-14 | 2015-11-25 | 46 | 60d | 0d |

| ID | WBS | Task | Duration | Start | Finish | Predecessors | Total slack | Free slack | Constraint |
| --- | --- | --- | --- | --- | --- | --- | --- | --- | --- |
| 54 | 2.1.5 | **iLCGT IFO Commissioning** | 543d | 2014-05-31 | 2015-11-24 |  | 31d |  |  |
| 55 | 2.1.5.1 | MC Lock | 2mo | 2014-05-31 | 2014-07-29 | 38 | 244d | 213d |  |
| 56 | 2.1.5.2 | X-arm | 3mo | 2015-02-28 | 2015-05-28 | 41, 42, 55, 21 | 31d | 0d |  |
| 57 | 2.1.5.3 | Michelson | 2mo | 2015-05-29 | 2015-07-27 | 43, 56, 23 | 31d | 0d |  |
| 58 | 2.1.5.4 | Y-arm | 2mo | 2015-07-28 | 2015-09-25 | 44, 57 | 31d | 0d |  |
| 59 | 2.1.5.5 | FPMI | 2mo | 2015-09-26 | 2015-11-24 | 58 | 31d | 0d |  |
| 60 | 2.1.6 | iLCGT Observation | 1mo | 2015-11-25 | 2015-12-24 | 59 | 31d | 0d |  |
| 61 | 2.2 | **bLCGT** | 1341d | 2015-12-25 | 2019-08-26 |  | 0d |  |  |
| 62 | 2.2.1 | **Change Suspensions** | 376d | 2015-12-25 | 2017-01-03 | 60 | 0d |  |  |
| 63 | 2.2.1.1 | ETM | 3mo | 2016-07-08 | 2016-10-05 | 48, 50, 4, 51FS-45d | 0d |  | start no earlier than 2014-09-01 |
| 64 | 2.2.1.2 | ITM | 3mo | 2016-10-06 | 2017-01-03 | 48FS-1mo, 5, 52, 63, 67 | 0d |  |  |
| 65 | 2.2.1.3 | Aux. Mirrors | 4.5mo | 2015-12-25 | 2016-05-07 | 53 | 31d | 0d |  |
| 66 | 2.2.2 | **Room Temp. RSE** | 481d | 2016-05-08 | 2017-08-31 |  | 0d |  |  |
| 67 | 2.2.2.1 | Silica DR Interferometer | 4mo | 2016-05-08 | 2016-09-04 | 65, 53 | 31d |  |  |
| 68 | 2.2.2.2 | PRMI | 1mo | 2017-01-04 | 2017-02-02 | 65, 64 | 0d |  |  |
| 69 | 2.2.2.3 | DRMI | 1mo | 2017-02-03 | 2017-03-04 | 68 | 0d |  |  |
| 70 | 2.2.2.4 | RSE | 6mo | 2017-03-05 | 2017-08-31 | 69 | 0d |  |  |
| 71 | 2.2.3 | Cryogenic RSE | 6mo | 2017-09-01 | 2018-02-27 | 66 | 0d |  |  |
| 72 | 2.2.4 | First Science Run | 1mo | 2018-02-28 | 2018-03-29 | 71 | 0d |  |  |
| 73 | 2.2.5 | IFO Tuning | 5mo | 2018-03-30 | 2018-08-26 | 72 | 0d |  |  |
| 74 | 2.2.6 | Observation | 365d | 2018-08-27 | 2019-08-26 | 73 | 0d |  |  |
